# Lab7Project_Base

Schedule from MS Project, 2004-03-01 to 2004-05-07.
University of California, Irvine

## Calendars

- Standard: Mon-Fri 08:00-12:00, 13:00-17:00; Sat-Sun off.

## Resources

| Resource |
| --- |
| Kate |
| Connor |

## Schedule

| ID | WBS | Task | Type | Duration | Start | Finish | Predecessors | Total slack | Free slack | Constraint | Resources | Work |
| --- | --- | --- | --- | --- | --- | --- | --- | --- | --- | --- | --- | --- |
| 1 | 1 | Project Launch | milestone | 0d | 2004-03-01 | 2004-03-01 |  | 50d |  |  |  |  |
| 2 | 2 | **Requirements and Specification** |  | 10d | 2004-03-01 | 2004-03-12 |  | 11d |  |  |  | 136h |
| 3 | 2.1 | Project Launch Meeting |  | 1d | 2004-03-01 | 2004-03-01 |  | 11d | 0d |  | Connor; Kate | 16h |
| 4 | 2.2 | Requirements Gathering |  | 3d | 2004-03-02 | 2004-03-04 | 3 | 11d | 0d |  | Connor | 24h |
| 5 | 2.3 | Specification |  | 5d | 2004-03-05 | 2004-03-11 | 4 | 11d | 0d |  | Connor; Kate | 80h |
| 6 | 2.4 | Client Meeting |  | 1d | 2004-03-12 | 2004-03-12 | 5 | 11d | 0d |  | Connor; Kate | 16h |
| 7 | 3 | Development Go-Ahead | milestone | 0d | 2004-03-12 | 2004-03-12 | 6 | 11d | 0d |  |  |  |
| 8 | 4 | Application Design |  | 5d | 2004-03-15 | 2004-03-19 | 7 | 11d | 0d |  | Kate; Connor | 80h |
| 9 | 5 | **Legacy Database Reader** |  | 9d | 2004-03-22 | 2004-04-01 | 8 | 14d | 11d |  |  | 72h |
| 10 | 5.1 | Legacy Database reader development |  | 6d | 2004-03-22 | 2004-03-29 |  | 14d | 0d | start no earlier than 2004-03-22 | Connor | 48h |
| 11 | 5.2 | Legacy Database reader Unit Testing |  | 3d | 2004-03-30 | 2004-04-01 | 10 | 14d |  | start no earlier than 2004-03-30 | Connor | 24h |
| 12 | 6 | **Web interface** |  | 12d | 2004-03-22 | 2004-04-06 | 8 | 11d | 8d |  |  | 96h |
| 13 | 6.1 | Web Interface Delevopment |  | 9d | 2004-03-22 | 2004-04-01 |  | 11d | 0d |  | Kate | 72h |
| 14 | 6.2 | Web Interface Unit Testing |  | 3d | 2004-04-02 | 2004-04-06 | 13 | 11d |  | start no earlier than 2004-04-02 | Kate | 24h |
| 15 | 7 | **MySql Writer** |  | 3d | 2004-04-02 | 2004-04-06 | 8 | 11d | 8d |  |  | 24h |
| 16 | 7.1 | MySql Writer Development |  | 2d | 2004-04-02 | 2004-04-05 |  | 11d | 0d | start no earlier than 2004-04-02 | Connor | 16h |
| 17 | 7.2 | MySql Writer Unit Testing |  | 1d | 2004-04-06 | 2004-04-06 | 16 | 11d |  |  | Connor | 8h |
| 18 | 8 | **Database Integrity Test Suite** |  | 8d | 2004-04-07 | 2004-04-16 | 8 | 3d | 0d |  |  | 64h |
| 19 | 8.1 | Database Integrity Tester Development |  | 4d | 2004-04-07 | 2004-04-12 |  | 3d | 0d | start no earlier than 2004-04-07 | Connor | 32h |
| 20 | 8.2 | Database Integrity Tester Unit Testing |  | 4d | 2004-04-13 | 2004-04-16 | 19 | 3d |  |  | Connor | 32h |
| 21 | 9 | **Core Application** |  | 8d | 2004-04-07 | 2004-04-16 | 8 | 3d | 0d |  |  | 64h |
| 22 | 9.1 | Core Application Development |  | 5d | 2004-04-07 | 2004-04-13 |  | 3d | 0d | start no earlier than 2004-04-07 | Kate | 40h |
| 23 | 9.2 | Core Appilcation Testing |  | 3d | 2004-04-14 | 2004-04-16 | 22 | 3d |  |  | Kate | 24h |
| 24 | 10 | **Final Integration and Testing** |  | 12d | 2004-04-19 | 2004-05-04 | 9, 12, 15, 18, 21 | 3d | 0d |  |  | 192h |
| 25 | 10.1 | Application Integration |  | 3d | 2004-04-19 | 2004-04-21 |  | 3d | 0d |  | Kate; Connor | 48h |
| 26 | 10.2 | Full System Testing and Debugging |  | 9d | 2004-04-22 | 2004-05-04 | 25 | 3d |  |  | Kate; Connor | 144h |

| ID | WBS | Task | Type | Duration | Start | Finish | Predecessors | Total slack | Free slack | Deadline | Resources | Work |
| --- | --- | --- | --- | --- | --- | --- | --- | --- | --- | --- | --- | --- |
| 27 | 11 | **Acceptance and Delivery** |  | 3d | 2004-05-05 | 2004-05-07 | 24 | 3d | 0d |  |  | 48h |
| 28 | 11.1 | Acceptance Trials |  | 2d | 2004-05-05 | 2004-05-06 |  | 3d | 0d |  | Kate; Connor | 32h |
| 29 | 11.2 | Delivery Meeting |  | 1d | 2004-05-07 | 2004-05-07 | 28 | 3d |  |  | Connor; Kate | 16h |
| 30 | 12 | Delivery | milestone | 0d | 2004-05-07 | 2004-05-07 | 27 | 3d |  | 2004-05-12 |  |  |
